# Technology Rollout - managing projects

How a schedule from MS Project changed from version to version. A marks actual dates.

## Version 1 (saved 2019-08-12, file Technology Rollout - Final.mpp)

| ID | WBS | Task | Duration | Start | Finish | Predecessors | Complete |
| --- | --- | --- | --- | --- | --- | --- | --- |
| 1 | 1 | **Phase One** | 9.25d | 2019-01-21 A | 2019-02-01 A |  | 100% |
| 2 |  | Survey staff for technology needs | 1w | 2019-01-21 A | 2019-01-25 A |  | 100% |
| 3 |  | Compile survey results | 1d | 2019-01-28 A | 2019-01-28 A | 2 | 100% |
| 4 |  | Send RFQ to vendors | 2h | 2019-01-29 A | 2019-01-29 A | 3 | 100% |
| 5 |  | Compare quotes | 2d | 2019-01-29 A | 2019-01-31 A | 4 | 100% |
| 6 |  | Order material | 1d | 2019-01-31 A | 2019-02-01 A | 5 | 100% |
| 7 |  | Phase One Complete | 0d | 2019-02-01 A | 2019-02-01 A | 6 | 100% |
| 8 | 2 | **Phase Two** | 6d | 2019-02-01 A | 2019-02-11 A |  | 100% |
| 9 |  | Pull/install cable | 1w | 2019-02-01 A | 2019-02-08 A | 7 | 100% |
| 10 |  | Install panel | 1d | 2019-02-01 A | 2019-02-04 A | 9SS | 100% |
| 11 |  | Connect and test | 1d | 2019-02-08 A | 2019-02-11 A | 9 | 100% |
| 12 |  | Phase Two Complete | 0d | 2019-02-11 A | 2019-02-11 A | 11 | 100% |
| 13 | 3 | **Phase Three** | 6d | 2019-02-11 A | 2019-02-19 A |  | 100% |
| 14 |  | Equipment placed | 1w | 2019-02-11 A | 2019-02-18 A | 12 | 100% |
| 15 |  | Install software/updates | 1d | 2019-02-18 A | 2019-02-19 A | 14 | 100% |
| 16 |  | Phase Three Complete | 0d | 2019-02-19 A | 2019-02-19 A | 15 | 100% |
| 17 | 4 | **Phase Four** | 23d | 2019-02-19 A | 2019-03-22 A |  | 100% |
| 18 |  | Survey staff for training needs | 1w | 2019-02-19 A | 2019-02-26 A | 16 | 100% |
| 19 |  | Compile survey results | 2d | 2019-02-26 A | 2019-02-28 A | 18 | 100% |
| 20 |  | Schedule sessions | 8h | 2019-02-28 A | 2019-03-01 A | 19 | 100% |
| 21 |  | Training | 2w | 2019-03-01 A | 2019-03-15 A | 20 | 100% |
| 22 |  | Post training survey | 1w | 2019-03-15 A | 2019-03-22 A | 21 | 100% |
| 23 |  | Phase Four Complete | 0d | 2019-03-22 A | 2019-03-22 A | 22 | 100% |

## Version 2 (saved 2019-08-12, file Technology Rollout.mpp)

Last finish 2019-03-22 → 2019-03-15 (-7d). Complete tasks 19 → 0.

Changed:

| ID | Task | Start | Finish | Duration | Complete | Total float | Predecessors | Other |
| --- | --- | --- | --- | --- | --- | --- | --- | --- |
| 1 | **Phase One** | 2019-01-21 A → 2019-01-21 | 2019-02-01 A → 2019-02-01 |  | 100% → 0% | none → -0.25d |  | baseline start 2013-03-04 → 2019-01-21; baseline finish 2013-03-15 → 2019-02-01 |
| 2 | Survey staff for technology needs | 2019-01-21 A → 2019-01-21 | 2019-01-25 A → 2019-01-25 |  | 100% → 0% | none → -0.25d |  | resources Information Technology Staff [200%] → Information Technology [200%]; baseline start 2013-03-04 → 2019-01-21; baseline finish 2013-03-08 → 2019-01-25 |
| 3 | Compile survey results | 2019-01-28 A → 2019-01-28 | 2019-01-28 A → 2019-01-28 |  | 100% → 0% | none → -0.25d |  | resources Information Technology Staff → Information Technology; baseline start 2013-03-11 → 2019-01-28; baseline finish 2013-03-11 → 2019-01-28 |
| 4 | Send RFQ to vendors | 2019-01-29 A → 2019-01-29 | 2019-01-29 A → 2019-01-29 |  | 100% → 0% | none → -0.25d |  | resources Information Technology Staff → Information Technology; baseline start 2013-03-12 → 2019-01-29; baseline finish 2013-03-12 → 2019-01-29 |
| 5 | Compare quotes | 2019-01-29 A → 2019-01-29 | 2019-01-31 A → 2019-01-31 |  | 100% → 0% | none → -0.25d |  | resources Information Technology Staff → Information Technology; baseline start 2013-03-12 → 2019-01-29; baseline finish 2013-03-14 → 2019-01-31 |
| 6 | Order material | 2019-01-31 A → 2019-01-31 | 2019-02-01 A → 2019-02-01 |  | 100% → 0% | none → -0.25d |  | resources Information Technology Staff → Information Technology; baseline start 2013-03-14 → 2019-01-31; baseline finish 2013-03-15 → 2019-02-01 |
| 7 | Phase One Complete | 2019-02-01 A → 2019-02-01 | 2019-02-01 A → 2019-02-01 |  | 100% → 0% | none → -0.25d |  | baseline start 2013-03-15 → 2019-02-01; baseline finish 2013-03-15 → 2019-02-01 |
| 8 | **Phase Two** | 2019-02-01 A → 2019-02-01 | 2019-02-11 A → 2019-02-08 (-3d) | 6d → 5d | 100% → 0% | none → -0.25d |  | baseline start 2013-03-15 → 2019-02-01; baseline finish 2013-03-25 → 2019-02-08 |
| 9 | Pull/install cable | 2019-02-01 A → 2019-02-01 | 2019-02-08 A → 2019-02-08 |  | 100% → 0% | none → -0.25d |  | baseline start 2013-03-15 → 2019-02-01; baseline finish 2013-03-22 → 2019-02-08 |
| 10 | Install panel | 2019-02-01 A → 2019-02-01 | 2019-02-04 A → 2019-02-04 |  | 100% → 0% | none → -0.25d |  | resources Network Vendor; Information Technology Staff → Information Technology; Network Vendor; baseline start 2013-03-15 → 2019-02-01; baseline finish 2013-03-18 → 2019-02-04 |
| 11 | Connect and test | 2019-02-08 A → 2019-02-04 (-4d) | 2019-02-11 A → 2019-02-05 (-6d) |  | 100% → 0% | none → -0.25d | 9 → 10 | resources Network Vendor; Information Technology Staff → Information Technology; Network Vendor; baseline start 2013-03-22 → 2019-02-04; baseline finish 2013-03-25 → 2019-02-05 |
| 12 | Phase Two Complete | 2019-02-11 A → 2019-02-05 (-6d) | 2019-02-11 A → 2019-02-05 (-6d) |  | 100% → 0% | none → -0.25d |  | baseline start 2013-03-25 → 2019-02-05; baseline finish 2013-03-25 → 2019-02-05 |
| 13 | **Phase Three** | 2019-02-11 A → 2019-02-05 (-6d) | 2019-02-19 A → 2019-02-12 (-7d) |  | 100% → 0% | none → 0d |  | baseline start 2013-04-01 → 2019-02-05; baseline finish 2013-04-08 → 2019-02-13 |
| 14 | Equipment placed | 2019-02-11 A → 2019-02-05 (-6d) | 2019-02-18 A → 2019-02-11 (-7d) |  | 100% → 0% | none → -0.25d |  | constraint none → finish no later than 2019-02-11; resources Product Vendor; Information Technology Staff → Product Vendor; Information Technology; baseline start 2013-04-01 → 2019-02-05; baseline finish 2013-04-05 → 2019-02-12 |
| 15 | Install software/updates | 2019-02-18 A → 2019-02-12 (-6d) | 2019-02-19 A → 2019-02-12 (-7d) |  | 100% → 0% | none → 0d |  | resources Information Technology Staff [400%] → Information Technology [400%]; baseline start 2013-04-08 → 2019-02-12; baseline finish 2013-04-08 → 2019-02-13 |
| 16 | Phase Three Complete | 2019-02-19 A → 2019-02-12 (-7d) | 2019-02-19 A → 2019-02-12 (-7d) |  | 100% → 0% | none → 0d |  | baseline start 2013-04-08 → 2019-02-13; baseline finish 2013-04-08 → 2019-02-13 |
| 17 | **Phase Four** | 2019-02-19 A → 2019-02-13 (-6d) | 2019-03-22 A → 2019-03-15 (-7d) | 23d → 22.5d | 100% → 0% | none → 0d |  | baseline start 2013-04-09 → 2019-02-13; baseline finish 2013-05-09 → 2019-03-15 |
| 18 | Survey staff for training needs | 2019-02-19 A → 2019-02-13 (-6d) | 2019-02-26 A → 2019-02-19 (-7d) |  | 100% → 0% | none → 0d |  | baseline start 2013-04-09 → 2019-02-13; baseline finish 2013-04-15 → 2019-02-20 |
| 19 | Compile survey results | 2019-02-26 A → 2019-02-20 (-6d) | 2019-02-28 A → 2019-02-21 (-7d) |  | 100% → 0% | none → 0d |  | baseline start 2013-04-16 → 2019-02-20; baseline finish 2013-04-17 → 2019-02-22 |
| 20 | Schedule Sessions | 2019-02-28 A → 2019-02-22 (-6d) | 2019-03-01 A → 2019-02-22 (-7d) | 8h → 4h | 100% → 0% | none → 0d |  | was named Schedule sessions; baseline start 2013-04-18 → 2019-02-22; baseline finish 2013-04-18 → 2019-02-22 |
| 21 | Training | 2019-03-01 A → 2019-02-22 (-7d) | 2019-03-15 A → 2019-03-08 (-7d) |  | 100% → 0% | none → 0d |  | resources Information Technology Staff [400%] → Information Technology [400%]; baseline start 2013-04-18 → 2019-02-22; baseline finish 2013-05-02 → 2019-03-08 |
| 22 | Post training survey | 2019-03-15 A → 2019-03-08 (-7d) | 2019-03-22 A → 2019-03-15 (-7d) |  | 100% → 0% | none → 0d |  | resources Information Technology Staff → Information Technology; baseline start 2013-05-02 → 2019-03-08; baseline finish 2013-05-09 → 2019-03-15 |
| 23 | Phase Four Complete | 2019-03-22 A → 2019-03-15 (-7d) | 2019-03-22 A → 2019-03-15 (-7d) |  | 100% → 0% | none → 0d |  | baseline start 2013-05-09 → 2019-03-15; baseline finish 2013-05-09 → 2019-03-15 |
