# Planning a Book Launch - Adding Notes

How a schedule from MS Project changed from version to version. A marks actual dates.

## Version 1 (saved 2019-08-12, file Planning a Book Launch - Baseline.mpp)

| ID | WBS | Task | Duration | Start | Finish | Predecessors | Total float |
| --- | --- | --- | --- | --- | --- | --- | --- |
| 1 | 1 | **Phase One** | 7d | 2019-01-21 | 2019-01-29 |  | 0d |
| 2 |  | Content Assessment | 0d | 2019-01-21 | 2019-01-21 |  | 0d |
| 3 |  | Outline Submission | 1w | 2019-01-21 | 2019-01-25 | 2 | 0d |
| 4 |  | Outline Approval | 2d | 2019-01-28 | 2019-01-29 | 3 | 0d |
| 5 |  | Phase One Complete | 0d | 2019-01-29 | 2019-01-29 | 4 | 0d |
| 6 | 2 | **Phase Two** | 35d | 2019-01-30 | 2019-03-19 |  | 0d |
| 7 |  | Content Research | 2w | 2019-01-30 | 2019-02-12 | 5 | 0d |
| 8 |  | Content Development | 3w | 2019-02-13 | 2019-03-05 | 7 | 0d |
| 9 |  | Content Edits | 2w | 2019-02-27 | 2019-03-12 | 8FS-1w | 0d |
| 10 |  | Content Review | 2w | 2019-03-06 | 2019-03-19 | 9FS-1w | 0d |
| 11 |  | Phase Two Complete | 0d | 2019-03-19 | 2019-03-19 | 10 | 40d |
| 12 | 3 | **Phase Three** | 25d | 2019-03-20 | 2019-04-23 |  | 0d |
| 13 |  | Media Research Options | 1w | 2019-03-20 | 2019-03-26 | 10 | 0d |
| 14 |  | Content Conversion for Media | 3w | 2019-03-27 | 2019-04-16 | 13 | 0d |
| 15 |  | Final Content Review | 1w | 2019-04-17 | 2019-04-23 | 14 | 0d |
| 16 |  | Phase Three Complete | 0d | 2019-04-23 | 2019-04-23 | 15 | 10d |
| 17 | 4 | **Phase Four** | 15d | 2019-04-24 | 2019-05-14 |  | 0d |
| 18 |  | Marketing Plan | 1w | 2019-04-24 | 2019-04-30 | 16 | 10d |
| 19 |  | Production | 2w | 2019-04-24 | 2019-05-07 | 15 | 0d |
| 20 |  | Delivery of Book to Market | 1w | 2019-05-08 | 2019-05-14 | 19 | 0d |
| 21 |  | Phase Four Complete | 0d | 2019-05-14 | 2019-05-14 | 20 | 0d |

## Version 2 (saved 2019-08-12, file Planning a Book Launch - Review.mpp)

Last finish stays 2019-05-14.

Changed:

| ID | Task | Other |
| --- | --- | --- |
| 1 | **Phase One** | baseline start 2019-01-21 → none; baseline finish 2019-01-29 → none |
| 2 | Content Assessment | baseline start 2019-01-21 → none; baseline finish 2019-01-21 → none |
| 3 | Outline Submission | baseline start 2019-01-21 → none; baseline finish 2019-01-25 → none |
| 4 | Outline Approval | baseline start 2019-01-28 → none; baseline finish 2019-01-29 → none |
| 5 | Phase One Complete | baseline start 2019-01-29 → none; baseline finish 2019-01-29 → none |
| 6 | **Phase Two** | baseline start 2019-01-30 → none; baseline finish 2019-03-19 → none |
| 7 | Content Research | baseline start 2019-01-30 → none; baseline finish 2019-02-12 → none |
| 8 | Content Development | baseline start 2019-02-13 → none; baseline finish 2019-03-05 → none |
| 9 | Content Edits | baseline start 2019-02-27 → none; baseline finish 2019-03-12 → none |
| 10 | Content Review | baseline start 2019-03-06 → none; baseline finish 2019-03-19 → none |
| 11 | Phase Two Complete | baseline start 2019-03-19 → none; baseline finish 2019-03-19 → none |
| 12 | **Phase Three** | baseline start 2019-03-20 → none; baseline finish 2019-04-23 → none |
| 13 | Media Research Options | baseline start 2019-03-20 → none; baseline finish 2019-03-26 → none |
| 14 | Content Conversion for Media | baseline start 2019-03-27 → none; baseline finish 2019-04-16 → none |
| 15 | Final Content Review | baseline start 2019-04-17 → none; baseline finish 2019-04-23 → none |
| 16 | Phase Three Complete | baseline start 2019-04-23 → none; baseline finish 2019-04-23 → none |
| 17 | **Phase Four** | baseline start 2019-04-24 → none; baseline finish 2019-05-14 → none |
| 18 | Marketing Plan | baseline start 2019-04-24 → none; baseline finish 2019-04-30 → none |
| 19 | Production | baseline start 2019-04-24 → none; baseline finish 2019-05-07 → none |
| 20 | Delivery of Book to Market | baseline start 2019-05-08 → none; baseline finish 2019-05-14 → none |
| 21 | Phase Four Complete | baseline start 2019-05-14 → none; baseline finish 2019-05-14 → none |

## Version 3 (saved 2019-08-12, file Planning a Book Launch - Baseline - Reports.mpp)

Last finish stays 2019-05-14.

Changed:

| ID | Task | Other |
| --- | --- | --- |
| 1 | **Phase One** | baseline start none → 2019-01-21; baseline finish none → 2019-01-29 |
| 2 | Content Assessment | baseline start none → 2019-01-21; baseline finish none → 2019-01-21 |
| 3 | Outline Submission | baseline start none → 2019-01-21; baseline finish none → 2019-01-25 |
| 4 | Outline Approval | baseline start none → 2019-01-28; baseline finish none → 2019-01-29 |
| 5 | Phase One Complete | baseline start none → 2019-01-29; baseline finish none → 2019-01-29 |
| 6 | **Phase Two** | baseline start none → 2019-01-30; baseline finish none → 2019-03-19 |
| 7 | Content Research | baseline start none → 2019-01-30; baseline finish none → 2019-02-12 |
| 8 | Content Development | baseline start none → 2019-02-13; baseline finish none → 2019-03-05 |
| 9 | Content Edits | baseline start none → 2019-02-27; baseline finish none → 2019-03-12 |
| 10 | Content Review | baseline start none → 2019-03-06; baseline finish none → 2019-03-19 |
| 11 | Phase Two Complete | baseline start none → 2019-03-19; baseline finish none → 2019-03-19 |
| 12 | **Phase Three** | baseline start none → 2019-03-20; baseline finish none → 2019-04-23 |
| 13 | Media Research Options | baseline start none → 2019-03-20; baseline finish none → 2019-03-26 |
| 14 | Content Conversion for Media | baseline start none → 2019-03-27; baseline finish none → 2019-04-16 |
| 15 | Final Content Review | baseline start none → 2019-04-17; baseline finish none → 2019-04-23 |
| 16 | Phase Three Complete | baseline start none → 2019-04-23; baseline finish none → 2019-04-23 |
| 17 | **Phase Four** | baseline start none → 2019-04-24; baseline finish none → 2019-05-14 |
| 18 | Marketing Plan | baseline start none → 2019-04-24; baseline finish none → 2019-04-30 |
| 19 | Production | baseline start none → 2019-04-24; baseline finish none → 2019-05-07 |
| 20 | Delivery of Book to Market | baseline start none → 2019-05-08; baseline finish none → 2019-05-14 |
| 21 | Phase Four Complete | baseline start none → 2019-05-14; baseline finish none → 2019-05-14 |

## Version 4 (saved 2019-08-12, file Planning a Book Launch - Record Progress.mpp)

Last finish 2019-05-14 → 2019-09-13 (+122d). Complete tasks 0 → 17.

Changed:

| ID | Task | Start | Finish | Duration | Complete | Total float |
| --- | --- | --- | --- | --- | --- | --- |
| 1 | **Phase One** | 2019-01-21 A | 2019-01-29 A |  | 0% → 100% | 0d → none |
| 2 | Content Assessment | 2019-01-21 A | 2019-01-21 A |  | 0% → 100% | 0d → none |
| 3 | Outline Submission | 2019-01-21 A | 2019-01-25 A |  | 0% → 100% | 0d → none |
| 4 | Outline Approval | 2019-01-28 A | 2019-01-29 A |  | 0% → 100% | 0d → none |
| 5 | Phase One Complete | 2019-01-29 A | 2019-01-29 A |  | 0% → 100% | 0d → none |
| 6 | **Phase Two** | 2019-01-30 A | 2019-03-19 A |  | 0% → 100% | 0d → none |
| 7 | Content Research | 2019-01-30 A | 2019-02-12 A |  | 0% → 100% | 0d → none |
| 8 | Content Development | 2019-02-13 A | 2019-03-05 A |  | 0% → 100% | 0d → none |
| 9 | Content Edits | 2019-02-27 A | 2019-03-12 A |  | 0% → 100% | 0d → none |
| 10 | Content Review | 2019-03-06 A | 2019-03-19 A |  | 0% → 100% | 0d → none |
| 11 | Phase Two Complete | 2019-03-19 A | 2019-03-19 A |  | 0% → 100% | 40d → none |
| 12 | **Phase Three** | 2019-03-20 A | 2019-04-23 → 2019-08-23 A (+122d) | 25d → 113d | 0% → 100% | 0d → none |
| 13 | Media Research Options | 2019-03-20 A | 2019-03-26 A |  | 0% → 100% | 0d → none |
| 14 | Content Conversion for Media | 2019-03-27 → 2019-04-01 A (+5d) | 2019-04-16 → 2019-08-16 A (+122d) | 3w → 20w | 0% → 100% | 0d → none |
| 15 | Final Content Review | 2019-04-17 → 2019-08-19 A (+124d) | 2019-04-23 → 2019-08-23 A (+122d) |  | 0% → 100% | 0d → none |
| 16 | Phase Three Complete | 2019-04-23 → 2019-08-23 A (+122d) | 2019-04-23 → 2019-08-23 A (+122d) |  | 0% → 100% | 10d → none |
| 17 | **Phase Four** | 2019-04-24 → 2019-08-26 A (+124d) | 2019-05-14 → 2019-09-13 A (+122d) |  | 0% → 100% | 0d → none |
| 18 | Marketing Plan | 2019-04-24 → 2019-08-26 A (+124d) | 2019-04-30 → 2019-08-30 A (+122d) |  | 0% → 100% | 10d → none |
| 19 | Production | 2019-04-24 → 2019-08-26 A (+124d) | 2019-05-07 → 2019-09-06 A (+122d) |  | 0% → 100% | 0d → none |
| 20 | Delivery of Book to Market | 2019-05-08 → 2019-09-09 A (+124d) | 2019-05-14 → 2019-09-13 A (+122d) |  | 0% → 100% | 0d → none |
| 21 | Phase Four Complete | 2019-05-14 → 2019-09-13 A (+122d) | 2019-05-14 → 2019-09-13 A (+122d) |  | 0% → 100% | 0d → none |
